# B.1_project_plan

Schedule from MS Project, 2006-11-01 to 2011-11-02.

## Calendars

- Standard: Mon-Fri 08:00-12:00, 13:00-17:00; Sat-Sun off. Exceptions (off unless hours are given): 2008-11-01 08:00-12:00, 13:00-17:00, 2009-01-31 08:00-12:00, 13:00-17:00, 2009-10-31 08:00-12:00, 13:00-17:00, 2010-01-31 08:00-12:00, 13:00-17:00, 2010-07-31 08:00-12:00, 13:00-17:00, 2010-10-31 08:00-12:00, 13:00-17:00, 2011-04-30 08:00-12:00, 13:00-17:00, 2011-07-31 08:00-12:00, 13:00-17:00.

## Schedule

| ID | WBS | Task | Type | Duration | Start | Finish | Predecessors | Total slack | Free slack | Constraint |
| --- | --- | --- | --- | --- | --- | --- | --- | --- | --- | --- |
| 1 | 1 | Definition of a holistic process map of production |  | 66d | 2006-11-01 | 2007-01-31 |  | 1248d | 0d | start no earlier than 2006-11-01 |
| 2 | 2 | Process map of production | milestone | 0d | 2007-01-31 | 2007-01-31 | 1 | 1248d |  |  |
| 3 | 3 | Identification of state-of-the-art simulation models (external and within the excellence cluster) |  | 75d | 2006-12-18 | 2007-03-30 |  | 1206d | 0d | finish no earlier than 2007-03-30 |
| 4 | 4 | Process map filled with models | milestone | 0d | 2007-03-30 | 2007-03-30 | 3 | 1206d |  |  |
| 5 | 5 | Identification of outputs and necessary inputs for all models (from processes, from other models and from external influenes) |  | 87d | 2007-03-01 | 2007-06-29 |  | 1141d | 0d | finish no earlier than 2007-06-29 |
| 6 | 6 | Inputs and outputs for all models | milestone | 0d | 2007-06-29 | 2007-06-29 | 5 | 1141d |  |  |
| 7 | 7 | **Identification of critical model parameters for stable information exchange** |  | 105d | 2007-06-18 | 2007-11-09 |  | 728d |  |  |
| 8 | 7.1 | Definition of correlations between models and their in- & outputs |  | 55d | 2007-06-18 | 2007-08-31 |  | 1046d | 0d | finish no earlier than 2007-08-31 |
| 9 | 7.2 | Correlation matrix | milestone | 0d | 2007-08-31 | 2007-08-31 | 8 | 1046d | 0d |  |
| 10 | 7.3 | Identification of correlation gaps and deficits concerning data quality, missing correlations and missing models |  | 50d | 2007-09-03 | 2007-11-09 | 9 | 1046d | 0d | finish no earlier than 2007-10-31 |
| 11 | 7.4 | Gap-matrix | milestone | 0d | 2007-11-09 | 2007-11-09 | 10 | 1046d |  |  |
| 12 | 7.5 | Detailed specification of requirements for WP A.2 |  | 43d | 2007-09-03 | 2007-10-31 |  | 673d | 0d | start no earlier than 2007-09-03 |
| 13 | 8 | **A.2 Semantic Connectivity for specific sub-models** |  | 180d | 2007-11-01 | 2008-07-09 | 12 | 673d | 62d |  |
| 14 | 8.1 | Quality, product, manufacturing process (WZL-MQ) |  | 180d | 2007-11-01 | 2008-07-09 |  | 673d |  | start no earlier than 2007-10-01 |
| 15 | 8.2 | Product, manufacturing process, material (WZL-TF) |  | 180d | 2007-11-01 | 2008-07-09 |  | 673d |  | start no earlier than 2007-10-01 |
| 16 | 8.3 | Logistics, factory design, product (WZL-PS) |  | 180d | 2007-11-01 | 2008-07-09 |  | 673d |  | start no earlier than 2007-10-01 |
| 17 | 8.4 | Business processes, work organisation (IPT 300) |  | 180d | 2007-11-01 | 2008-07-09 |  | 673d |  | start no earlier than 2007-10-01 |
| 18 | 9 | **Specification of information needs to cover the functional interdependencies** |  | 261d | 2008-10-06 | 2009-10-01 | 13 | 550d |  |  |
| 19 | 9.1 | Framework for information exchange between sub-models |  | 150d | 2008-10-06 | 2009-04-29 |  | 661d |  | start no earlier than 2008-10-06 |
| 20 | 9.2 | Criteria to ensure disjunctive transfer of information between sub-models |  | 200d | 2008-12-29 | 2009-10-01 |  | 550d |  | start no earlier than 2008-12-29 |
| 21 | 10 | Definition of necessary information flow between sub-models |  | 180d | 2009-06-29 | 2010-03-03 |  | 439d |  | start no earlier than 2009-06-29 |
| 22 | 11 | Requirements specification for translators and information models |  | 150d | 2009-09-28 | 2010-04-21 |  | 204d | 0d | start no earlier than 2009-09-28 |
| 23 | 12 | **A.3 Development of entire model map for information exchange** |  | 404d | 2010-04-22 | 2011-11-02 | 22 | 0d |  |  |
| 24 | 12.1 | Development of translators and information exchange models |  | 170d | 2010-04-22 | 2010-12-13 |  | 234d |  | start no earlier than 2009-11-02 |
| 25 | 12.2 | Information transfer functions |  | 140d | 2010-05-03 | 2010-11-10 |  | 257d |  | start no earlier than 2010-05-03 |
| 26 | 12.3 | Development of standards for an integrated quality assessment of product and manufacturing process characteristics regarding simulations as well as required supplementing information (WZL-MQ) |  | 200d | 2010-09-27 | 2011-06-29 |  | 91d |  | start no earlier than 2010-09-27 |
| 27 | 12.4 | Controlling mechanisms to ensure destinct allocation of required and perceived information between the semantic sub-models (IPT 300) |  | 200d | 2011-01-31 | 2011-11-02 |  | 0d |  | start no earlier than 2011-01-31 |
